# SamplePortalProject

Schedule from MS Project, 2006-08-01 to 2007-05-03, status date 2006-01-01.
IBM

## Calendars

- Standard: Mon-Fri 08:00-12:00, 13:00-17:00; Sat-Sun off.

## Resources

| Resource |
| --- |
| Development Lead |
| IBM Sales |
| IBM Tech Sales |
| Project Owner |
| Project Manager |
| Infrastructure Lead |
| Architect |
| IBM Services |
| Test Lead |
| Developers |

## Schedule

| ID | WBS | Task | Type | Duration | Start | Finish | Predecessors | Total slack | Free slack | Constraint | Resources | Work |
| --- | --- | --- | --- | --- | --- | --- | --- | --- | --- | --- | --- | --- |
| 1 | 1 | **Overall Notes** |  | 1d? | 2006-08-01 | 2006-08-01 |  | 0d |  |  |  |  |
| 2 | 1.1 | Sample WebSphere Portal and WCM Project Plan V5.1a | milestone | 0d | 2006-08-01 | 2006-08-01 |  | 0d |  | start no earlier than 2006-08-01 |  |  |
| 3 | 1.2 | Prepared by: |  | 1d? | 2006-08-01 | 2006-08-01 |  | 0d |  | start no earlier than 2006-08-01 |  |  |
| 4 | 1.3 | ***ALL DURATIONS VERY ROUGH ESTIMATES*** | milestone | 0d | 2006-08-01 | 2006-08-01 |  | 0d |  | start no earlier than 2006-08-01 |  |  |
| 5 | 2 | **Pre-reqs** |  | 5d? | 2006-08-01 | 2006-08-07 |  | 0d |  |  |  | 40h |
| 6 | 2.1 | ROI Study | milestone | 0d | 2006-08-01 | 2006-08-01 |  | 0d |  | start no earlier than 2006-08-01 |  |  |
| 7 | 2.2 | IBM Solution Assurance Review |  | 5d? | 2006-08-01 | 2006-08-07 |  | 0d |  | start no earlier than 2006-08-01 | IBM Tech Sales | 40h |
| 8 | 3 | **Project Startup** |  | 17d? | 2006-08-01 | 2006-08-23 | 2 | 0d |  |  |  | 376h |
| 9 | 3.1 | **Objectives** |  | 4d? | 2006-08-01 | 2006-08-04 |  | 13d |  |  |  | 56h |
| 10 | 3.1.1 | Identify Stakeholders |  | 0.5d? | 2006-08-01 | 2006-08-01 |  | 22.5d | 1.5d |  | Project Owner | 4h |
| 11 | 3.1.2 | Identify Primary Objectives |  | 2d? | 2006-08-01 | 2006-08-02 |  | 21d | 0d |  | Project Owner | 16h |
| 12 | 3.1.3 | Identify Key Constaints |  | 0.5d? | 2006-08-01 | 2006-08-01 |  | 22.5d | 1.5d |  | Project Owner | 4h |
| 13 | 3.1.4 | Objectives Review |  | 2d | 2006-08-03 | 2006-08-04 | 10, 11, 12 | 21d |  |  | Project Owner; IBM Services | 32h |
| 14 | 3.2 | **Staffing** |  | 5d? | 2006-08-01 | 2006-08-07 |  | 0d |  |  |  | 120h |
| 15 | 3.2.1 | Identify Project Manager | milestone | 0d | 2006-08-01 | 2006-08-01 |  | 0d |  |  | Project Owner |  |
| 16 | 3.2.2 | **Leadership Education** |  | 0.5d | 2006-08-01 | 2006-08-01 |  | 16.5d |  |  |  | 8h |
| 17 | 3.2.2.1 | Building Web Applications Overview |  | 4h | 2006-08-01 | 2006-08-01 |  | 24.5d |  |  | Project Owner; Project Manager | 8h |
| 18 | 3.2.3 | **Technical Team** |  | 5d? | 2006-08-01 | 2006-08-07 |  | 12d |  |  |  | 112h |
| 19 | 3.2.3.1 | Skills Assessment |  | 2d? | 2006-08-01 | 2006-08-02 |  | 23d |  |  | IBM Services; Project Manager | 32h |
| 20 | 3.2.3.2 | Best Practice: Plan a small core team (3-to-8) people of strong, diverse skills | milestone | 0d | 2006-08-01 | 2006-08-01 |  | 25d |  |  | Project Manager |  |
| 21 | 3.2.3.3 | **Skills Enhancement** |  | 5d | 2006-08-01 | 2006-08-07 |  | 12d |  |  |  | 80h |
| 22 | 3.2.3.3.1 | **Developer Education** |  | 5d | 2006-08-01 | 2006-08-07 |  | 12d |  |  |  |  |
| 23 | 3.2.3.3.1.1 | OO and Java for Developers | milestone | 0d | 2006-08-01 | 2006-08-01 |  | 12d | 0d |  | Developers |  |
| 24 | 3.2.3.3.1.2 | WebSphere Application Server | milestone | 0d | 2006-08-01 | 2006-08-01 | 23 | 12d | 0d |  | Developers |  |

Notes:
- 22: Fewer courses might be needed, depending on the skills assessments.

| ID | WBS | Task | Type | Duration | Start | Finish | Predecessors | Total slack | Free slack | Resources | Work |
| --- | --- | --- | --- | --- | --- | --- | --- | --- | --- | --- | --- |
| 25 | 3.2.3.3.1.3 | **WebSphere Portal Development** |  | 5d | 2006-08-01 | 2006-08-07 | 24 | 12d |  |  |  |
| 26 | 3.2.3.3.1.3.1 | Rational Application Developer / Eclipse | milestone | 0d | 2006-08-01 | 2006-08-01 |  | 17d | 0d | Developers |  |
| 27 | 3.2.3.3.1.3.2 | JSR 168 | milestone | 0d | 2006-08-01 | 2006-08-01 | 26 | 17d | 0d | Developers |  |
| 28 | 3.2.3.3.1.3.3 | Themes & Skins | milestone | 0d | 2006-08-01 | 2006-08-01 | 27 | 17d | 0d | Developers |  |
| 29 | 3.2.3.3.1.3.4 | Struts or JSF, if desired | milestone | 0d | 2006-08-01 | 2006-08-01 | 28 | 17d |  | Developers |  |
| 30 | 3.2.3.3.1.3.5 | IWWCM Content Creation |  | 5d | 2006-08-01 | 2006-08-07 |  | 12d |  |  |  |
| 31 | 3.2.3.3.2 | **Operations Education** |  | 5d | 2006-08-01 | 2006-08-07 |  | 12d |  |  | 80h |
| 32 | 3.2.3.3.2.1 | WebSphere Application Server |  | 5d | 2006-08-01 | 2006-08-07 |  | 12d |  | Infrastructure Lead | 40h |
| 33 | 3.2.3.3.2.2 | WebSphere Portal Server |  | 5d | 2006-08-01 | 2006-08-07 |  | 12d |  | Infrastructure Lead | 40h |
| 34 | 3.3 | **Project Management** |  | 17d | 2006-08-01 | 2006-08-23 | 15 | 0d |  |  | 200h |
| 35 | 3.3.1 | Determine status reporting approach |  | 3d | 2006-08-01 | 2006-08-03 |  | 14d |  | Project Owner; Project Manager | 48h |
| 36 | 3.3.2 | **Create/Track Microsoft Project Plan** |  | 17d | 2006-08-01 | 2006-08-23 |  | 0d |  |  | 152h |
| 37 | 3.3.2.1 | Define Plan |  | 15d | 2006-08-01 | 2006-08-21 |  | 0d |  | Project Manager | 120h |
| 38 | 3.3.2.2 | Review with IBM |  | 2d | 2006-08-22 | 2006-08-23 | 37 | 0d |  | Project Manager; IBM Services | 32h |
| 39 | 3.3.2.3 | Identify key milesteons/interim demos/executive checkpoints | milestone | 0d | 2006-08-21 | 2006-08-21 | 37 | 2d |  | Project Owner; Project Manager |  |
| 40 | 4 | **Solution Definition** |  | 33d? | 2006-08-24 | 2006-10-09 | 8 | 0d |  |  | 784h |
| 41 | 4.1 | Document Requirements (5 days to 20 days) |  | 20d? | 2006-08-24 | 2006-09-20 |  | 13d |  | Project Owner | 160h |
| 42 | 4.2 | **Architecture Workshop (3 to 5 days plus documentation)** |  | 4.5d? | 2006-08-24 | 2006-08-30 |  | 28.5d | 0d |  | 160h |
| 43 | 4.2.1 | Customer Requirements Review (business, performance, UI, etc) |  | 4h | 2006-08-24 | 2006-08-24 |  | 31d | 0d | IBM Services; Project Manager; Architect; Project Owner | 16h |
| 44 | 4.2.2 | Review gotchas |  | 1d? | 2006-08-24 | 2006-08-25 | 43 | 31d | 0d |  |  |
| 45 | 4.2.3 | WAS and Portal Technical Discussion |  | 4h | 2006-08-25 | 2006-08-25 | 44 | 31d |  | IBM Services; Architect; Project Manager | 12h |
| 46 | 4.2.4 | **Review WCM install planning** |  | 2d? | 2006-08-24 | 2006-08-25 |  | 31d |  |  |  |
| 47 | 4.2.4.1 | Select architecture |  | 1d? | 2006-08-24 | 2006-08-24 |  | 32d |  |  |  |
| 48 | 4.2.4.2 | Legacy site content migration |  | 2d | 2006-08-24 | 2006-08-25 |  | 31d |  |  |  |
| 49 | 4.2.5 | Physical Architecture |  | 2h | 2006-08-24 | 2006-08-24 |  | 32d | 0d | IBM Services; Architect; Project Manager | 6h |
| 50 | 4.2.6 | Security/Single Signon/Directory Approach |  | 2h | 2006-08-24 | 2006-08-24 | 49 | 32d | 0d | IBM Services; Architect; Project Manager | 6h |
| 51 | 4.2.7 | Personalization, Content Mgmt, Search |  | 2h | 2006-08-24 | 2006-08-24 | 50 | 32d | 0d | IBM Services; Architect; Project Manager | 6h |
| 52 | 4.2.8 | UI, Themes and Skins, Wireframes, etc. |  | 2h | 2006-08-24 | 2006-08-24 | 51 | 32d | 0d | IBM Services; Architect; Project Manager | 6h |
| 53 | 4.2.9 | Best Practice: Introduce wireframes and "Portlet Sourcing" | milestone | 0d | 2006-08-24 | 2006-08-24 | 52 | 32d |  |  |  |

Notes:
- 34: The actual number of days for project management will be very specific to the individual project.
- 41: The length of requirements gathering depends on many factors, such as scope and complexity of business goals, availability of key personel, number of pages, number of backends, etc. We highly recommend wireframes and the Portlet Sourcing technique to determine detailed requirements.
- 42: The length of the workshop depends on how much experience the organization has with WebSphere and Java, whether the organization has a definite Portal project scope in mind, and whether they are reworking the enterprise architecture around Portal.

| ID | WBS | Task | Type | Duration | Start | Finish | Predecessors | Total slack | Free slack | Resources | Work |
| --- | --- | --- | --- | --- | --- | --- | --- | --- | --- | --- | --- |
| 54 | 4.2.10 | **Development environment** |  | 2d | 2006-08-24 | 2006-08-25 |  | 28.5d |  | IBM Services; Architect; Project Manager | 48h |
| 55 | 4.2.10.1 | Capacity planning |  | 2d | 2006-08-24 | 2006-08-25 |  | 28.5d | 0d |  |  |
| 56 | 4.2.11 | **Production environment** |  | 2d | 2006-08-28 | 2006-08-29 | 55 | 28.5d |  | IBM Services; Architect; Project Manager | 48h |
| 57 | 4.2.11.1 | Capacity planning |  | 2d | 2006-08-28 | 2006-08-29 |  | 28.5d | 0d |  |  |
| 58 | 4.2.12 | Project planning, risks, and next steps |  | 2h | 2006-08-30 | 2006-08-30 | 57 | 28.5d | 0d | IBM Services; Architect; Project Manager | 6h |
| 59 | 4.2.13 | Wrapup |  | 2h | 2006-08-30 | 2006-08-30 | 58 | 28.5d |  | IBM Services; Architect; Project Manager | 6h |
| 60 | 4.3 | **Deliverable: Architecture Workshop Summary** |  | 7d | 2006-08-24 | 2006-09-01 |  | 26d |  |  | 120h |
| 61 | 4.3.1 | Document Key Decisions and Recommendations |  | 2d | 2006-08-24 | 2006-08-25 |  | 26d | 0d | IBM Services; Architect; Project Manager | 48h |
| 62 | 4.3.2 | Document UI (rough diagrams) |  | 2d | 2006-08-28 | 2006-08-29 | 61 | 26d | 0d | IBM Services; Architect | 32h |
| 63 | 4.3.3 | Identify Risks / Open Issues |  | 1d | 2006-08-30 | 2006-08-30 | 62 | 26d | 0d | IBM Services; Architect; Project Manager | 24h |
| 64 | 4.3.4 | Review and Approval | milestone | 2d | 2006-08-31 | 2006-09-01 | 63 | 26d |  | Project Owner | 16h |
| 65 | 4.4 | **Software Products Selected** |  | 0d | 2006-08-30 | 2006-08-30 | 42 | 28.5d | 0d | Architect; IBM Services |  |
| 66 | 4.4.1 | These tasks are zero days each; this is used to document selected products | milestone | 0d | 2006-08-30 | 2006-08-30 |  | 28.5d |  |  |  |
| 67 | 4.4.2 | WebSphere Portal Express | milestone | 0d | 2006-08-30 | 2006-08-30 |  | 28.5d |  |  |  |
| 68 | 4.4.3 | WebSphere Portal Express Plus | milestone | 0d | 2006-08-30 | 2006-08-30 |  | 28.5d |  |  |  |
| 69 | 4.4.4 | **WebSphere Portal Enable** |  | 0d | 2006-08-30 | 2006-08-30 |  | 28.5d |  |  |  |
| 70 | 4.4.4.1 | IBM HTTP Server | milestone | 0d | 2006-08-30 | 2006-08-30 |  | 28.5d |  |  |  |
| 71 | 4.4.4.2 | WebSphere Application Server | milestone | 0d | 2006-08-30 | 2006-08-30 |  | 28.5d |  |  |  |
| 72 | 4.4.4.3 | WebSphere Portal | milestone | 0d | 2006-08-30 | 2006-08-30 |  | 28.5d |  |  |  |
| 73 | 4.4.4.4 | Rational Application Developer | milestone | 0d | 2006-08-30 | 2006-08-30 |  | 28.5d |  |  |  |
| 74 | 4.4.4.5 | WebSphere Portal Application Integrator | milestone | 0d | 2006-08-30 | 2006-08-30 |  | 28.5d |  |  |  |
| 75 | 4.4.4.6 | Portal Document Manager | milestone | 0d | 2006-08-30 | 2006-08-30 |  | 28.5d |  |  |  |
| 76 | 4.4.4.7 | Lightweight Office Components | milestone | 0d | 2006-08-30 | 2006-08-30 |  | 28.5d |  |  |  |
| 77 | 4.4.4.8 | Workplace Web Content Management | milestone | 0d | 2006-08-30 | 2006-08-30 |  | 28.5d |  |  |  |
| 78 | 4.4.4.9 | WebSphere Personalization | milestone | 0d | 2006-08-30 | 2006-08-30 |  | 28.5d |  |  |  |
| 79 | 4.4.4.10 | Portal Search Engine | milestone | 0d | 2006-08-30 | 2006-08-30 |  | 28.5d |  |  |  |
| 80 | 4.4.4.11 | IBM Directory Server | milestone | 0d | 2006-08-30 | 2006-08-30 |  | 28.5d |  |  |  |
| 81 | 4.4.4.12 | Portal Database (e.g. DB2) | milestone | 0d | 2006-08-30 | 2006-08-30 |  | 28.5d |  |  |  |

Notes:
- 65: Delete, modify, or add products as appropriate. The "duration" for each should be zero as all are assumed to be covered in the architecture and design workshop.

| ID | WBS | Task | Type | Duration | Start | Finish | Predecessors | Total slack | Resources |
| --- | --- | --- | --- | --- | --- | --- | --- | --- | --- |
| 82 | 4.4.5 | **WebSphere Portal Extend** |  | 0d | 2006-08-30 | 2006-08-30 |  | 28.5d |  |
| 83 | 4.4.5.1 | Best Practice: Don't include too much in first release! See note. | milestone | 0d | 2006-08-30 | 2006-08-30 |  | 28.5d |  |
| 84 | 4.4.5.2 | Extended Search | milestone | 0d | 2006-08-30 | 2006-08-30 |  | 28.5d |  |
| 85 | 4.4.5.3 | Lotus Instance Messaging (Sametime) | milestone | 0d | 2006-08-30 | 2006-08-30 |  | 28.5d |  |
| 86 | 4.4.5.4 | Lotus Team Workplaces (Quickplaces) | milestone | 0d | 2006-08-30 | 2006-08-30 |  | 28.5d |  |
| 87 | 4.4.5.5 | Collaboration Center | milestone | 0d | 2006-08-30 | 2006-08-30 |  | 28.5d |  |
| 88 | 4.4.5.6 | Lotus Collaborative Services APIs / Online Awareness | milestone | 0d | 2006-08-30 | 2006-08-30 |  | 28.5d |  |
| 89 | 4.4.5.7 | Tivoli Web Site Analzyer | milestone | 0d | 2006-08-30 | 2006-08-30 |  | 28.5d |  |
| 90 | 4.4.6 | **Complementary IBM Products** |  | 0d | 2006-08-30 | 2006-08-30 |  | 28.5d |  |
| 91 | 4.4.6.1 | WebSphere Edge Server | milestone | 0d | 2006-08-30 | 2006-08-30 |  | 28.5d |  |
| 92 | 4.4.6.2 | Tivoli Access Manager | milestone | 0d | 2006-08-30 | 2006-08-30 |  | 28.5d |  |
| 93 | 4.4.6.3 | Tivoli Identity Manager | milestone | 0d | 2006-08-30 | 2006-08-30 |  | 28.5d |  |
| 94 | 4.4.6.4 | IBM (DB2) Content Manager | milestone | 0d | 2006-08-30 | 2006-08-30 |  | 28.5d |  |
| 95 | 4.4.6.5 | Business Process Choreographer | milestone | 0d | 2006-08-30 | 2006-08-30 |  | 28.5d |  |
| 96 | 4.4.6.6 | WebSphere Business Integration (for SOA) | milestone | 0d | 2006-08-30 | 2006-08-30 |  | 28.5d |  |
| 97 | 4.4.6.7 | WebSphere Translation Server | milestone | 0d | 2006-08-30 | 2006-08-30 |  | 28.5d |  |
| 98 | 4.4.6.8 | WebSphere Studio Application Monitor | milestone | 0d | 2006-08-30 | 2006-08-30 |  | 28.5d |  |
| 99 | 4.4.7 | **Complementary Third-Party Products** |  | 0d | 2006-08-30 | 2006-08-30 |  | 28.5d |  |
| 100 | 4.4.7.1 | Bowstreet Portlet Factory | milestone | 0d | 2006-08-30 | 2006-08-30 |  | 28.5d |  |
| 101 | 4.4.7.2 | External Security Manager | milestone | 0d | 2006-08-30 | 2006-08-30 |  | 28.5d |  |
| 102 | 4.4.7.3 | Load Testing Tool | milestone | 0d | 2006-08-30 | 2006-08-30 |  | 28.5d |  |
| 103 | 4.4.7.4 | Performance Monitoring and Alert Tool | milestone | 0d | 2006-08-30 | 2006-08-30 |  | 28.5d |  |
| 104 | 4.5 | **Hardware Selected** |  | 0d | 2006-08-30 | 2006-08-30 | 42, 65 | 28.5d | Architect; IBM Services |
| 105 | 4.5.1 | **Development Environment** |  | 0d | 2006-08-30 | 2006-08-30 |  | 28.5d |  |
| 106 | 4.5.1.1 | Portal Server(s): Operating System, Memory, Processor, etc. | milestone | 0d | 2006-08-30 | 2006-08-30 |  | 28.5d |  |
| 107 | 4.5.1.2 | Collaboration Server(s) | milestone | 0d | 2006-08-30 | 2006-08-30 |  | 28.5d |  |
| 108 | 4.5.1.3 | Database Servers | milestone | 0d | 2006-08-30 | 2006-08-30 |  | 28.5d |  |
| 109 | 4.5.1.4 | Edge Servers | milestone | 0d | 2006-08-30 | 2006-08-30 |  | 28.5d |  |
| 110 | 4.5.1.5 | Directory Servers | milestone | 0d | 2006-08-30 | 2006-08-30 |  | 28.5d |  |
| 111 | 4.5.1.6 | Other Servers | milestone | 0d | 2006-08-30 | 2006-08-30 |  | 28.5d |  |

Notes:
- 83: Although the organization may select Extend, our recommendation is that the functions in Enable are best for the initial pilot phase, with maybe one aspect of Extend investigated during the pilot phase.

| ID | WBS | Task | Type | Duration | Start | Finish | Predecessors | Total slack | Free slack | Resources | Work |
| --- | --- | --- | --- | --- | --- | --- | --- | --- | --- | --- | --- |
| 112 | 4.5.2 | **Staging Environment** |  | 0d | 2006-08-30 | 2006-08-30 |  | 28.5d |  |  |  |
| 113 | 4.5.2.1 | Portal Server(s): Operating System, Memory, Processor, etc. | milestone | 0d | 2006-08-30 | 2006-08-30 |  | 28.5d |  |  |  |
| 114 | 4.5.2.2 | Collaboration Server(s) | milestone | 0d | 2006-08-30 | 2006-08-30 |  | 28.5d |  |  |  |
| 115 | 4.5.2.3 | Database Servers | milestone | 0d | 2006-08-30 | 2006-08-30 |  | 28.5d |  |  |  |
| 116 | 4.5.2.4 | Edge Servers | milestone | 0d | 2006-08-30 | 2006-08-30 |  | 28.5d |  |  |  |
| 117 | 4.5.2.5 | Directory Servers | milestone | 0d | 2006-08-30 | 2006-08-30 |  | 28.5d |  |  |  |
| 118 | 4.5.2.6 | Other Servers | milestone | 0d | 2006-08-30 | 2006-08-30 |  | 28.5d |  |  |  |
| 119 | 4.5.3 | **Production Environment** |  | 0d | 2006-08-30 | 2006-08-30 |  | 28.5d |  |  |  |
| 120 | 4.5.3.1 | Portal Server(s): Operating System, Memory, Processor, etc. | milestone | 0d | 2006-08-30 | 2006-08-30 |  | 28.5d |  |  |  |
| 121 | 4.5.3.2 | Collaboration Server(s) | milestone | 0d | 2006-08-30 | 2006-08-30 |  | 28.5d |  |  |  |
| 122 | 4.5.3.3 | Database Servers | milestone | 0d | 2006-08-30 | 2006-08-30 |  | 28.5d |  |  |  |
| 123 | 4.5.3.4 | Edge Servers | milestone | 0d | 2006-08-30 | 2006-08-30 |  | 28.5d |  |  |  |
| 124 | 4.5.3.5 | Directory Servers | milestone | 0d | 2006-08-30 | 2006-08-30 |  | 28.5d |  |  |  |
| 125 | 4.5.3.6 | Other Servers | milestone | 0d | 2006-08-30 | 2006-08-30 |  | 28.5d |  |  |  |
| 126 | 4.6 | **Post Workshop Planning and Design** |  | 33d | 2006-08-24 | 2006-10-09 |  | 0d |  |  | 344h |
| 127 | 4.6.1 | Scope and Propose Services |  | 2d | 2006-08-24 | 2006-08-25 |  | 28d | 0d | Project Manager; IBM Services | 32h |
| 128 | 4.6.2 | Create draft milestone plan (update this mpp) |  | 3d | 2006-08-28 | 2006-08-30 | 127 | 28d |  | Project Manager | 24h |
| 129 | 4.6.3 | **Detailed design documentation** |  | 30d | 2006-08-24 | 2006-10-04 |  | 0d |  |  | 240h |
| 130 | 4.6.3.1 | Phase 0-2 (Pilot) |  | 15d | 2006-08-24 | 2006-09-13 |  | 0d |  | Architect | 120h |
| 131 | 4.6.3.2 | Phase 3-4 (Release) |  | 15d | 2006-09-14 | 2006-10-04 | 130 | 0d |  | Architect | 120h |
| 132 | 4.6.4 | Review and approval of detailed design |  | 3d | 2006-10-05 | 2006-10-09 | 129 | 0d |  | Architect; Project Manager | 48h |
| 133 | 5 | **Establish Project Standards / Best Practices** |  | 2.5d? | 2006-08-30 | 2006-09-01 | 42 | 48d |  |  | 40h |
| 134 | 5.1 | Review Best Practices |  | 1d? | 2006-08-30 | 2006-08-31 |  | 49.5d |  |  |  |
| 135 | 5.2 | Establish Change Management Procedures |  | 0.5d | 2006-08-30 | 2006-08-30 |  | 48d | 0d | Project Manager; Development Lead | 8h |
| 136 | 5.3 | Establish Documentation Standards |  | 0.5d | 2006-08-31 | 2006-08-31 | 135 | 48d | 0d | Project Manager; Development Lead | 8h |
| 137 | 5.4 | Establish Development Standards |  | 0.5d | 2006-08-31 | 2006-08-31 | 136 | 48d | 0d | Development Lead | 4h |
| 138 | 5.5 | Document Development Procedures |  | 0.5d | 2006-09-01 | 2006-09-01 | 137 | 48d | 0d | Development Lead | 4h |
| 139 | 5.6 | Establish Testing Standards |  | 0.5d | 2006-08-30 | 2006-08-30 |  | 49.5d | 1.5d | Test Lead | 4h |
| 140 | 5.7 | Establish Content Creation Standards |  | 1d? | 2006-08-30 | 2006-08-31 |  | 49.5d |  |  |  |
| 141 | 5.8 | Establish Deployment Standards |  | 0.5d | 2006-08-30 | 2006-08-30 |  | 48.5d | 0d | Infrastructure Lead | 4h |

Notes:
- 133: The actual amount of time each of the standards takes to document depends largely on where the organization is on the Software Engineering Institute's CMM scale. (See http://www.sei.cmu.edu/.) Also, the calendar time this supertask takes depends on how much simultaneity can be achieved in the subtasks.

| ID | WBS | Task | Type | Duration | Start | Finish | Predecessors | Total slack | Free slack | Resources | Work |
| --- | --- | --- | --- | --- | --- | --- | --- | --- | --- | --- | --- |
| 142 | 5.9 | **Review WCM install planning** |  | 1d? | 2006-08-31 | 2006-08-31 | 141 | 48.5d |  |  |  |
| 143 | 5.9.1 | Select architecture |  | 1d? | 2006-08-31 | 2006-08-31 |  | 48.5d | 0.5d |  |  |
| 144 | 5.10 | Summarize and review in Project Standards document |  | 0.5d | 2006-09-01 | 2006-09-01 | 139, 138, 143 | 48d |  | Architect; Project Manager | 8h |
| 145 | 6 | **Environment Setup (Dev, QA, Prod)** |  | 92.5d? | 2006-10-09 | 2007-02-15 | 40 | 0d |  |  | 1172h |
| 146 | 6.1 | Document Directory (LDAP) Schema and Design (10 to 20 days) |  | 20d? | 2006-10-10 | 2006-11-06 |  | 0d |  | Infrastructure Lead | 160h |
| 147 | 6.2 | **Establish Development Environment** |  | 22d | 2006-10-09 | 2006-11-08 |  | 0d |  |  | 220h |
| 148 | 6.2.1 | Procure Hardware | milestone | 0d | 2006-10-09 | 2006-10-09 |  | 4d | 0d | Project Owner |  |
| 149 | 6.2.2 | Install Hardware |  | 5d | 2006-10-10 | 2006-10-16 | 148 | 4d | 0d | Project Owner | 40h |
| 150 | 6.2.3 | Procure Software | milestone | 0d | 2006-10-16 | 2006-10-16 | 149 | 4d | 0d | Project Owner |  |
| 151 | 6.2.4 | **Build Development Infrastructure** |  | 17d | 2006-10-17 | 2006-11-08 | 150 | 0d |  |  | 180h |
| 152 | 6.2.4.1 | Install IBM Support Assistant v3 |  | 2h | 2006-10-17 | 2006-10-17 |  | 16.75d |  |  |  |
| 153 | 6.2.4.2 | **Install Development Integration Servers** |  | 17d | 2006-10-17 | 2006-11-08 |  | 0d |  |  | 64h |
| 154 | 6.2.4.2.1 | Install Operating System |  | 1d | 2006-10-17 | 2006-10-17 |  | 13d | 0d | Development Lead | 8h |
| 155 | 6.2.4.2.2 | Install Development Repository |  | 1d | 2006-10-18 | 2006-10-18 | 154 | 13d | 0d | Development Lead | 8h |
| 156 | 6.2.4.2.3 | Configure Development Repository |  | 2d | 2006-10-19 | 2006-10-20 | 155 | 13d |  | Development Lead | 16h |
| 157 | 6.2.4.2.4 | Install HTTP Server |  | 1d | 2006-10-18 | 2006-10-18 | 154 | 13d | 0d | Development Lead | 8h |
| 158 | 6.2.4.2.5 | Install Portal Database |  | 1d | 2006-10-19 | 2006-10-19 | 157 | 13d |  | Development Lead | 8h |
| 159 | 6.2.4.2.6 | Install Directory Server |  | 1d | 2006-11-07 | 2006-11-07 | 146, 155 | 0d |  | Development Lead | 8h |
| 160 | 6.2.4.2.7 | Install Application Server/Portal Server |  | 1d | 2006-11-08 | 2006-11-08 | 159, 158 | 0d |  | Development Lead | 8h |
| 161 | 6.2.4.3 | **Create Initial Developer Configuration** |  | 13d | 2006-10-17 | 2006-11-02 |  | 4d |  |  | 104h |
| 162 | 6.2.4.3.1 | Install Portal |  | 0.5d | 2006-10-17 | 2006-10-17 |  | 4d | 0d | Development Lead | 4h |
| 163 | 6.2.4.3.2 | Configure connection to Portal Database |  | 0.5d | 2006-10-17 | 2006-10-17 | 162 | 4d | 0d | Development Lead | 4h |
| 164 | 6.2.4.3.3 | Configure connection to Directory Server |  | 0.5d | 2006-10-18 | 2006-10-18 | 163 | 4d | 0d | Development Lead | 4h |
| 165 | 6.2.4.3.4 | Install Rational Application Developer |  | 0.5d | 2006-10-18 | 2006-10-18 | 164 | 4d | 0d | Development Lead | 4h |
| 166 | 6.2.4.3.5 | Confirm install |  | 1d | 2006-10-19 | 2006-10-19 | 165 | 4d | 0d | Development Lead | 8h |
| 167 | 6.2.4.3.6 | Replicate to all developers (1-2 days/developer) |  | 10d | 2006-10-20 | 2006-11-02 | 166 | 4d |  | Developers | 80h |

Notes:
- 146: The duration is highly dependent on how far along an organization is in its road to having a directory architecture and infrastructure in place.

| ID | WBS | Task | Type | Duration | Start | Finish | Predecessors | Total slack | Free slack | Resources | Work |
| --- | --- | --- | --- | --- | --- | --- | --- | --- | --- | --- | --- |
| 168 | 6.2.4.4 | **Confirm Installation** |  | 0.75d | 2006-10-17 | 2006-10-17 | 150 | 16.25d |  |  | 12h |
| 169 | 6.2.4.4.1 | Confirm DB connections |  | 1h | 2006-10-17 | 2006-10-17 |  | 16.25d | 0d | Infrastructure Lead; Development Lead | 2h |
| 170 | 6.2.4.4.2 | Confirm WAS (e.g. snoop servlet) |  | 1h | 2006-10-17 | 2006-10-17 | 169 | 16.25d | 0d | Infrastructure Lead; Development Lead | 2h |
| 171 | 6.2.4.4.3 | Confirm Portal Login |  | 1h | 2006-10-17 | 2006-10-17 | 170 | 16.25d | 0d | Infrastructure Lead; Development Lead | 2h |
| 172 | 6.2.4.4.4 | Use admin to create/deploy places and portlets |  | 1h | 2006-10-17 | 2006-10-17 | 171 | 16.25d | 0d | Infrastructure Lead; Development Lead | 2h |
| 173 | 6.2.4.4.5 | Confirm basic portlet function with user login |  | 1h | 2006-10-17 | 2006-10-17 | 172 | 16.25d | 0d | Infrastructure Lead; Development Lead | 2h |
| 174 | 6.2.4.4.6 | Confirm security/authorizations work |  | 1h | 2006-10-17 | 2006-10-17 | 173 | 16.25d |  | Infrastructure Lead; Development Lead | 2h |
| 175 | 6.3 | **Establish Staging/QA/Pilot Environment** |  | 24d? | 2006-10-09 | 2006-11-10 | 40 | 27.5d |  |  | 232h |
| 176 | 6.3.1 | Procure Hardware | milestone | 0d | 2006-10-09 | 2006-10-09 |  | 27.5d | 0d | Project Owner |  |
| 177 | 6.3.2 | Install Hardware |  | 5d | 2006-10-10 | 2006-10-16 | 176 | 27.5d | 0d | Project Owner | 40h |
| 178 | 6.3.3 | Procure Software | milestone | 0d | 2006-10-16 | 2006-10-16 | 177 | 27.5d | 0d | Project Owner |  |
| 179 | 6.3.4 | **Install Software** |  | 16d | 2006-10-17 | 2006-11-07 | 178 | 27.5d |  |  | 152h |
| 180 | 6.3.4.1 | **Install Servers** |  | 5d | 2006-10-17 | 2006-10-23 |  | 27.5d | 0d |  | 40h |
| 181 | 6.3.4.1.1 | Install Operating System |  | 1d | 2006-10-17 | 2006-10-17 |  | 27.5d | 0d | Infrastructure Lead | 8h |
| 182 | 6.3.4.1.2 | Install HTTP Server |  | 1d | 2006-10-18 | 2006-10-18 | 181 | 27.5d | 0d | Infrastructure Lead | 8h |
| 183 | 6.3.4.1.3 | Install Portal Database Server |  | 1d | 2006-10-19 | 2006-10-19 | 182 | 27.5d | 0d | Infrastructure Lead | 8h |
| 184 | 6.3.4.1.4 | Install Directory Server |  | 1d | 2006-10-20 | 2006-10-20 | 183 | 27.5d | 0d | Infrastructure Lead | 8h |
| 185 | 6.3.4.1.5 | Install Application Server/Portal Server |  | 1d | 2006-10-23 | 2006-10-23 | 184 | 27.5d |  | Infrastructure Lead | 8h |
| 186 | 6.3.4.2 | Configure Portal Server to use DB and LDAP |  | 1d | 2006-10-24 | 2006-10-24 | 180 | 27.5d | 0d | Infrastructure Lead | 8h |
| 187 | 6.3.4.3 | Configure Cloning/Clustering for WAS |  | 10d | 2006-10-25 | 2006-11-07 | 186 | 27.5d | 0d | Infrastructure Lead | 80h |
| 188 | 6.3.4.4 | Configure Cloning/Clustering for Sametime/QuickPlace |  | 3d | 2006-10-24 | 2006-10-26 | 180 | 38.5d |  | Infrastructure Lead | 24h |
| 189 | 6.3.5 | Install/configure Performance Tool |  | 2d | 2006-10-10 | 2006-10-11 |  | 49.5d |  | Infrastructure Lead | 16h |
| 190 | 6.3.6 | Best Practice: Baseline your performance before application is installed | milestone | 0d | 2006-10-09 | 2006-10-09 |  | 51.5d |  |  |  |
| 191 | 6.3.7 | Confirm Installation for each server | milestone | 3d? | 2006-11-08 | 2006-11-10 | 187 | 27.5d |  | Infrastructure Lead | 24h |
| 192 | 6.3.8 | Replicate WCM content |  | 5d | 2006-10-10 | 2006-10-16 |  | 46.5d |  |  |  |

Notes:
- 192: When first creating a new WCM application, it is better to copy an existing WCM data repository database to a new server, enable your new WCM application to use the new data repository, and then enable Syndication rather than trying to Syndicate an entire Site's data.

| ID | WBS | Task | Type | Duration | Start | Finish | Predecessors | Total slack | Free slack | Resources | Work |
| --- | --- | --- | --- | --- | --- | --- | --- | --- | --- | --- | --- |
| 193 | 6.4 | **Establish Production Environment** |  | 25d? | 2007-01-11 | 2007-02-15 | 218 | 14.5d |  |  | 560h |
| 194 | 6.4.1 | Procure Hardware | milestone | 0d? | 2007-01-11 | 2007-01-11 |  | 14.5d | 0d | Project Owner |  |
| 195 | 6.4.2 | Install Hardware |  | 1d? | 2007-01-11 | 2007-01-12 | 194 | 14.5d | 0d | Project Owner | 8h |
| 196 | 6.4.3 | Procure Software |  | 1d? | 2007-01-12 | 2007-01-15 | 195 | 14.5d | 0d | Project Owner | 8h |
| 197 | 6.4.4 | **Install Software** |  | 20d? | 2007-01-15 | 2007-02-12 | 196 | 14.5d |  |  | 336h |
| 198 | 6.4.4.1 | Develop/Test Install Guide/Scripts (Ant) |  | 5d | 2007-01-15 | 2007-01-22 |  | 32.5d |  | Infrastructure Lead | 40h |
| 199 | 6.4.4.2 | **Install Servers** |  | 10d? | 2007-01-15 | 2007-01-29 |  | 17.5d | 0d |  | 160h |
| 200 | 6.4.4.2.1 | Install Operating System |  | 1d | 2007-01-15 | 2007-01-16 |  | 17.5d | 0d | Infrastructure Lead | 8h |
| 201 | 6.4.4.2.2 | Install HTTP Server |  | 1d | 2007-01-16 | 2007-01-17 | 200 | 17.5d | 0d | Infrastructure Lead | 8h |
| 202 | 6.4.4.2.3 | Install Portal Database Server |  | 1d | 2007-01-17 | 2007-01-18 | 201 | 17.5d | 0d | Infrastructure Lead | 8h |
| 203 | 6.4.4.2.4 | Install Directory Server |  | 1d | 2007-01-18 | 2007-01-19 | 202 | 17.5d | 0d | Infrastructure Lead | 8h |
| 204 | 6.4.4.2.5 | Install WebSphere Application Server/Portal Server |  | 1d | 2007-01-19 | 2007-01-22 | 203 | 17.5d | 0d | Infrastructure Lead | 8h |
| 205 | 6.4.4.2.6 | Install Extended Search |  | 3d | 2007-01-16 | 2007-01-19 | 200 | 23.5d |  | Infrastructure Lead | 24h |
| 206 | 6.4.4.2.7 | Install Lotus Collaboration Servers (Sametime and QuickPlace) |  | 4d | 2007-01-16 | 2007-01-22 | 200 | 22.5d |  | Infrastructure Lead | 32h |
| 207 | 6.4.4.2.8 | Install Collaboration Center |  | 2d | 2007-01-16 | 2007-01-18 | 200 | 24.5d |  | Infrastructure Lead | 16h |
| 208 | 6.4.4.2.9 | Install Tivoli Web Site Analzyer |  | 1d | 2007-01-22 | 2007-01-23 | 204 | 21.5d |  | Infrastructure Lead | 8h |
| 209 | 6.4.4.2.10 | Install Tivoli Access Manager TAI on WAS |  | 5d | 2007-01-22 | 2007-01-29 | 204 | 17.5d |  | Infrastructure Lead | 40h |
| 210 | 6.4.4.2.11 | Install Other Software Components | milestone | 0d? | 2007-01-15 | 2007-01-15 |  | 27.5d |  | Infrastructure Lead |  |
| 211 | 6.4.4.3 | Configure Clustering for WAS/WP |  | 10d | 2007-01-29 | 2007-02-12 | 199 | 17.5d |  | Infrastructure Lead | 80h |
| 212 | 6.4.4.4 | Configure Clustering for Sametime/QuickPlace |  | 2d | 2007-01-29 | 2007-01-31 | 199 | 25.5d |  | Infrastructure Lead | 16h |
| 213 | 6.4.4.5 | Confirm Installation for each server |  | 5d | 2007-01-15 | 2007-01-22 |  | 14.5d | 0d | Infrastructure Lead | 40h |
| 214 | 6.4.5 | Deploy Tested Portal/Portlets |  | 5d | 2007-01-22 | 2007-01-29 | 213, 229 | 14.5d | 0d | Development Lead; Test Lead; Infrastructure Lead | 120h |
| 215 | 6.4.6 | Replicate WCM content |  | 5d | 2007-01-29 | 2007-02-05 | 214 | 14.5d | 0d |  |  |
| 216 | 6.4.7 | Document Operator Procedures |  | 5d | 2007-02-05 | 2007-02-12 | 215 | 14.5d | 0d | Infrastructure Lead | 40h |
| 217 | 6.4.8 | Operator Training |  | 3d | 2007-02-12 | 2007-02-15 | 216 | 14.5d |  | Infrastructure Lead; Project Owner | 48h |

Notes:
- 209: Assumes that Tivoli Access Manager is already install. Installation of TAM is outside the scope of this project.
- 210: There may be other software selected for the production solution, including legacy connectors, ERP systems, WebSphere MQ, etc. This task is highly dependent on the specific project.
- 215: When first creating a new WCM application, it is better to copy an existing WCM data repository database to a new server, enable your new WCM application to use the new data repository, and then enable Syndication rather than trying to Syndicate an entire Site's data.

| ID | WBS | Task | Type | Duration | Start | Finish | Predecessors | Total slack | Resources | Work |
| --- | --- | --- | --- | --- | --- | --- | --- | --- | --- | --- |
| 218 | 7 | **Pilot Development (build basic function)** |  | 45.5d? | 2006-11-08 | 2007-01-11 | 133, 40, 147 | 0d |  | 912h |
| 219 | 7.1 | Objective: Implement out-of-the-box function & limited custom function | milestone | 0d | 2006-11-08 | 2006-11-08 |  | 45.5d |  |  |
| 220 | 7.2 | **Design** |  | 9.5d | 2006-11-09 | 2006-11-22 | 40 | 0d |  | 184h |
| 221 | 7.2.1 | Assign custom development tasks |  | 2.5d | 2006-11-09 | 2006-11-13 |  | 0d | Project Manager | 20h |
| 222 | 7.2.2 | **Document design(s) for custom portlets** |  | 2d | 2006-11-13 | 2006-11-15 | 221 | 3d |  | 20h |
| 223 | 7.2.2.1 | Select Design Approach, Framework (e.g. Struts), and Tools |  | 2d | 2006-11-13 | 2006-11-15 |  | 3d | Developers | 16h |
| 224 | 7.2.2.2 | Best Practice: Complete Portlet Sourcing Worksheet |  | 0.5d | 2006-11-13 | 2006-11-13 |  | 4.5d | Developers | 4h |
| 225 | 7.2.3 | Document design for changes to backend systems |  | 5d | 2006-11-13 | 2006-11-20 | 221 | 0d | Architect | 40h |
| 226 | 7.2.4 | Document design for UI including themes and skins |  | 2d | 2006-11-13 | 2006-11-15 | 221 | 3d | Development Lead | 16h |
| 227 | 7.2.5 | Document use/test cases |  | 5d | 2006-11-13 | 2006-11-20 | 221 | 0d | Test Lead | 40h |
| 228 | 7.2.6 | Review designs |  | 2d | 2006-11-20 | 2006-11-22 | 222, 146, 225, 226, 227 | 0d | Development Lead; Architect; Project Manager | 48h |
| 229 | 7.3 | **Build** |  | 29.5d | 2006-11-09 | 2006-12-20 | 40 | 0d |  | 448h |
| 230 | 7.3.1 | **Iterative Development** |  | 29.5d | 2006-11-09 | 2006-12-20 |  | 0d |  | 448h |
| 231 | 7.3.1.1 | **Develop/test phase 0** |  | 3d | 2006-11-09 | 2006-11-13 |  | 6.5d |  | 48h |
| 232 | 7.3.1.1.1 | Develop/test out-of-the-box function |  | 3d | 2006-11-09 | 2006-11-13 | 147 | 6.5d | Development Lead; Infrastructure Lead | 48h |
| 233 | 7.3.1.2 | **Develop/test phase 1 of custom development** |  | 15d | 2006-11-22 | 2006-12-13 | 220, 231 | 0d |  | 200h |
| 234 | 7.3.1.2.1 | Rebrand Themes & Skins |  | 10d | 2006-11-22 | 2006-12-06 |  | 5d | Development Lead | 80h |
| 235 | 7.3.1.2.2 | **A few (3-5) simple custom portlets of various types** |  | 15d | 2006-11-22 | 2006-12-13 |  | 0d |  | 120h |
| 236 | 7.3.1.2.2.1 | Portlet 1a: (e.g. iFrame) |  | 2d | 2006-11-22 | 2006-11-24 |  | 0d | Developers | 16h |
| 237 | 7.3.1.2.2.2 | Portlet 1b: (e.g. clipping) |  | 3d | 2006-11-24 | 2006-11-29 | 236 | 0d | Developers | 24h |
| 238 | 7.3.1.2.2.3 | Portlet 1c: (e.g. custom using RAD) |  | 10d | 2006-11-29 | 2006-12-13 | 237 | 0d | Developers | 80h |
| 239 | 7.3.1.2.2.4 | etc. | milestone | 0d | 2006-12-13 | 2006-12-13 | 238 | 0d | Developers |  |
| 240 | 7.3.1.3 | **Develop/test phase 2 of custom development** |  | 5d | 2006-12-13 | 2006-12-20 | 233 | 0d |  | 200h |
| 241 | 7.3.1.3.1 | **5 additional custom portlets** |  | 5d | 2006-12-13 | 2006-12-20 |  | 0d |  | 200h |
| 242 | 7.3.1.3.1.1 | Portlet 2a: |  | 5d | 2006-12-13 | 2006-12-20 |  | 0d | Developers | 40h |
| 243 | 7.3.1.3.1.2 | Portlet 2b: |  | 5d | 2006-12-13 | 2006-12-20 |  | 0d | Developers | 40h |
| 244 | 7.3.1.3.1.3 | Portlet 2c: |  | 5d | 2006-12-13 | 2006-12-20 |  | 0d | Developers | 40h |
| 245 | 7.3.1.3.1.4 | Portlet 2d: |  | 5d | 2006-12-13 | 2006-12-20 |  | 0d | Developers | 40h |
| 246 | 7.3.1.3.1.5 | Portlet 2e: |  | 5d | 2006-12-13 | 2006-12-20 |  | 0d | Developers | 40h |

Notes:
- 218: In some projects, the pilot delivers a majority of function to some users. How much function is delivered to which users is highly specific to a particular project. In our experience it is best if a pilot restricts itself to 3-to-5 different out-of-the-box portlets and 3-to-5 custom portlets with no more than moderate complexity. We would also recommend keeping it to about 3 pages.
- 220: Although this project plan (due to tool limitations) represents the design/build/deployment as a linear process, in fact agile methodologies (such as Extreme Programming) lend themselves well to Portal development. Needless to say, traditional methodologies (such as the Rational Unified Process) can also be used.
- 229: The number of iterations and their content is highly specific to the individual project.

| ID | WBS | Task | Type | Duration | Start | Finish | Predecessors | Total slack | Free slack | Resources | Work |
| --- | --- | --- | --- | --- | --- | --- | --- | --- | --- | --- | --- |
| 247 | 7.4 | **Migrate Legacy WCM content** |  | 10d | 2006-11-09 | 2006-11-22 |  | 35.5d |  |  | 144h |
| 248 | 7.4.1 | Map Schemas |  | 10d | 2006-11-09 | 2006-11-22 |  | 35.5d |  | Architect | 80h |
| 249 | 7.4.2 | XML Transforms |  | 5d | 2006-11-09 | 2006-11-15 |  | 40.5d |  | Architect | 40h |
| 250 | 7.4.3 | Import to Aptrix tables |  | 3d | 2006-11-09 | 2006-11-13 |  | 42.5d |  | Infrastructure Lead | 24h |
| 251 | 7.5 | **Integration test** |  | 15d? | 2006-12-20 | 2007-01-10 | 229 | 0d |  |  | 120h |
| 252 | 7.5.1 | QA/Integration Testing in Development Environment |  | 15d? | 2006-12-20 | 2007-01-10 |  | 0d |  | Test Lead | 120h |
| 253 | 7.6 | Demo the Pilot to your executives! | milestone | 1d | 2007-01-10 | 2007-01-11 | 252 | 0d |  | Project Owner; Architect | 16h |
| 254 | 8 | **Pilot Release (release basic function)** |  | 36d? | 2006-12-20 | 2007-02-08 |  | 0d |  |  | 736h |
| 255 | 8.1 | **Test** |  | 36d? | 2006-12-20 | 2007-02-08 | 133, 175, 229 | 0d |  |  | 736h |
| 256 | 8.1.1 | **System Test** |  | 10d? | 2006-12-20 | 2007-01-03 | 40 | 0d |  |  | 160h |
| 257 | 8.1.1.1 | Execute Use Cases |  | 10d? | 2006-12-20 | 2007-01-03 | 233, 227 | 0d |  | Test Lead | 80h |
| 258 | 8.1.1.2 | Develop Backup/Recovery Procedures |  | 5d | 2006-12-20 | 2006-12-27 |  | 0d |  | Infrastructure Lead | 40h |
| 259 | 8.1.1.3 | Test Backup/Recovery Procedures |  | 5d | 2006-12-27 | 2007-01-03 | 258, 229 | 0d |  | Infrastructure Lead | 40h |
| 260 | 8.1.2 | **Performance/Stress Test** |  | 30d | 2006-12-20 | 2007-01-31 |  | 0d |  |  | 320h |
| 261 | 8.1.2.1 | Develop Performance Scripts |  | 5d | 2006-12-20 | 2006-12-27 | 233 | 10d |  | Infrastructure Lead; Test Lead | 80h |
| 262 | 8.1.2.2 | Stress Testing |  | 5d | 2007-01-10 | 2007-01-17 | 261, 251 | 0d |  | Infrastructure Lead; Test Lead | 80h |
| 263 | 8.1.2.3 | Failover Testing |  | 5d | 2007-01-17 | 2007-01-24 | 262 | 0d |  | Infrastructure Lead; Test Lead | 80h |
| 264 | 8.1.2.4 | Adjust and confirm |  | 5d | 2007-01-24 | 2007-01-31 | 263 | 0d |  | Infrastructure Lead; Test Lead | 80h |
| 265 | 8.1.3 | **Deployment** |  | 36d? | 2006-12-20 | 2007-02-08 | 175 | 0d |  |  | 256h |
| 266 | 8.1.3.1 | Develop/Test Install Guide/Scripts (ANT) |  | 5d | 2006-12-20 | 2006-12-27 |  | 0d |  | Infrastructure Lead | 40h |
| 267 | 8.1.3.2 | Deploy Tested Portal/Portlets |  | 5d | 2006-12-20 | 2006-12-27 |  | 20d | 0d | Infrastructure Lead | 40h |
| 268 | 8.1.3.3 | Update Operator Procedures |  | 5d | 2006-12-27 | 2007-01-03 | 267 | 20d | 0d | Infrastructure Lead | 40h |
| 269 | 8.1.3.4 | Conduct Operator Training |  | 3d | 2007-01-03 | 2007-01-08 | 268 | 20d |  | Infrastructure Lead | 24h |
| 270 | 8.1.3.5 | Establish End User Documentation/Training | milestone | 0d? | 2006-12-20 | 2006-12-20 |  | 0d |  | Project Owner |  |
| 271 | 8.1.3.6 | Deployment Readiness Assessment |  | 3d | 2007-01-31 | 2007-02-05 | 267, 260 | 0d |  | Infrastructure Lead; IBM Services | 48h |
| 272 | 8.1.3.7 | Go/No-Go Decision |  | 1d | 2007-02-05 | 2007-02-06 | 269, 271 | 0d |  | Project Owner | 8h |
| 273 | 8.1.3.8 | Go Live |  | 1d | 2007-02-06 | 2007-02-07 | 272 | 0d |  | Project Owner | 8h |
| 274 | 8.1.3.9 | Issue Management |  | 2d | 2007-02-06 | 2007-02-08 | 272 | 0d |  | Project Owner; Project Manager; Architect | 48h |

| ID | WBS | Task | Type | Duration | Start | Finish | Predecessors | Total slack | Resources | Work |
| --- | --- | --- | --- | --- | --- | --- | --- | --- | --- | --- |
| 275 | 9 | **Production Release** |  | 75.5d? | 2007-01-11 | 2007-04-26 | 218 | 0d |  | 1280h |
| 276 | 9.1 | **Design** |  | 9.5d | 2007-01-11 | 2007-01-24 | 229 | 0d |  | 224h |
| 277 | 9.1.1 | Assign custom development tasks |  | 2.5d | 2007-01-11 | 2007-01-15 |  | 0d | Project Manager | 20h |
| 278 | 9.1.2 | **Document design(s) for custom portlets** |  | 2d | 2007-01-16 | 2007-01-17 | 277 | 5d |  | 20h |
| 279 | 9.1.2.1 | Select Design Approach |  | 2d | 2007-01-16 | 2007-01-17 |  | 5d | Developers | 16h |
| 280 | 9.1.2.2 | Best Practice: Complete Portlet Sourcing Worksheet |  | 0.5d | 2007-01-16 | 2007-01-16 |  | 6.5d | Developers | 4h |
| 281 | 9.1.3 | Document design for changes to backend systems |  | 5d | 2007-01-16 | 2007-01-22 | 277 | 0d | Architect | 40h |
| 282 | 9.1.4 | Document Content Schema Design |  | 5d | 2007-01-16 | 2007-01-22 | 277 | 0d | Architect | 40h |
| 283 | 9.1.5 | Document design for UI including themes and skins |  | 2d | 2007-01-16 | 2007-01-17 | 277 | 3d | Development Lead | 16h |
| 284 | 9.1.6 | Review and update use/test cases |  | 5d | 2007-01-16 | 2007-01-22 | 277 | 0d | Test Lead | 40h |
| 285 | 9.1.7 | Review designs |  | 2d | 2007-01-23 | 2007-01-24 | 281, 283, 284, 282 | 0d | Development Lead; Architect; Project Manager | 48h |
| 286 | 9.2 | **Build** |  | 30d? | 2007-01-24 | 2007-03-07 | 276 | 0d |  | 240h |
| 287 | 9.2.1 | **Interative Development** |  | 30d? | 2007-01-24 | 2007-03-07 |  | 0d |  | 240h |
| 288 | 9.2.1.1 | Develop/test phase 3 of custom development |  | 15d | 2007-01-25 | 2007-02-14 |  | 0d | Developers | 120h |
| 289 | 9.2.1.2 | Develop/test phase 4 of custom development |  | 15d | 2007-02-15 | 2007-03-07 | 288 | 20d | Developers | 120h |
| 290 | 9.2.1.3 | **Content Development** |  | 0d? | 2007-01-24 | 2007-01-24 |  | 50d |  |  |
| 291 | 9.2.1.3.1 | Content Inventory | milestone | 0d? | 2007-01-24 | 2007-01-24 |  | 50d | Development Lead |  |
| 292 | 9.2.1.3.2 | Content Written | milestone | 0d? | 2007-01-24 | 2007-01-24 |  | 50d | Development Lead |  |
| 293 | 9.2.1.3.3 | Content Tagged | milestone | 0d? | 2007-01-24 | 2007-01-24 |  | 50d | Development Lead |  |
| 294 | 9.2.1.3.4 | Content Complete | milestone | 0d? | 2007-01-24 | 2007-01-24 |  | 50d | Development Lead |  |
| 295 | 9.3 | **Test** |  | 35d? | 2007-02-15 | 2007-04-04 |  | 0d |  | 440h |
| 296 | 9.3.1 | QA/IntegrationTesting |  | 10d? | 2007-02-15 | 2007-02-28 | 288 | 0d | Test Lead | 80h |
| 297 | 9.3.2 | System Test |  | 5d? | 2007-03-01 | 2007-03-07 | 296 | 0d | Test Lead | 40h |
| 298 | 9.3.3 | **Performance/Stress Test** |  | 20d | 2007-03-08 | 2007-04-04 | 193, 297 | 0d |  | 320h |
| 299 | 9.3.3.1 | Develop Performance Scripts |  | 5d | 2007-03-08 | 2007-03-14 |  | 0d | Test Lead; Infrastructure Lead | 80h |
| 300 | 9.3.3.2 | Stress Testing |  | 5d | 2007-03-15 | 2007-03-21 | 299 | 0d | Test Lead; Infrastructure Lead | 80h |
| 301 | 9.3.3.3 | Failover Testing |  | 5d | 2007-03-22 | 2007-03-28 | 300 | 0d | Test Lead; Infrastructure Lead | 80h |
| 302 | 9.3.3.4 | Adjust and confirm |  | 5d | 2007-03-29 | 2007-04-04 | 301 | 0d | Test Lead; Infrastructure Lead | 80h |

Notes:
- 275: The production release is sometimes referred to as "Release 1." This is because most IT systems go thru several release cycles. This basic pattern can be repeated for each release.
- 290: Most portals deliver dynamic content, web pages that are selected based on some customization or personalization. But the actual nature of each organization is so different, no general guidelines for task time can be made.

| ID | WBS | Task | Type | Duration | Start | Finish | Predecessors | Total slack | Resources | Work |
| --- | --- | --- | --- | --- | --- | --- | --- | --- | --- | --- |
| 303 | 9.4 | **Deployment** |  | 36d? | 2007-03-07 | 2007-04-26 | 286 | 0d |  | 376h |
| 304 | 9.4.1 | Develop/Test Install Guide/Scripts (Ant) |  | 5d | 2007-03-08 | 2007-03-14 |  | 31d | Infrastructure Lead | 40h |
| 305 | 9.4.2 | Deploy Tested Portal/Portlets |  | 10d | 2007-04-05 | 2007-04-18 | 295 | 4d | Infrastructure Lead | 80h |
| 306 | 9.4.3 | Develop/Test Disaster Recovery Procedures |  | 5d | 2007-04-05 | 2007-04-11 | 295 | 0d | Infrastructure Lead | 40h |
| 307 | 9.4.4 | Document Operator Procedures |  | 5d | 2007-04-12 | 2007-04-18 | 306 | 0d | Infrastructure Lead | 40h |
| 308 | 9.4.5 | Operator Training |  | 1d? | 2007-04-19 | 2007-04-19 | 307 | 0d | Infrastructure Lead; Project Owner | 16h |
| 309 | 9.4.6 | Establish End User Documentation/Training | milestone | 0d? | 2007-03-07 | 2007-03-07 | 286 | 31d | Project Owner |  |
| 310 | 9.4.7 | Deployment Readiness Assessment |  | 3d | 2007-04-20 | 2007-04-24 | 309, 308 | 0d | Infrastructure Lead; Project Owner; Project Manager; IBM Services | 96h |
| 311 | 9.4.8 | Go/No-Go Decision |  | 1d? | 2007-04-25 | 2007-04-25 | 310, 305 | 0d | Project Owner | 8h |
| 312 | 9.4.9 | Go Live |  | 1d? | 2007-04-26 | 2007-04-26 | 311 | 0d | Project Owner | 8h |
| 313 | 9.4.10 | Issue Management |  | 2d | 2007-03-08 | 2007-03-09 |  | 34d | Project Owner; Project Manager; Architect | 48h |
| 314 | 10 | **Project Close** |  | 5d | 2007-04-27 | 2007-05-03 | 275 | 0d |  | 96h |
| 315 | 10.1 | **Review Results vs. Objectives** |  | 2d | 2007-04-27 | 2007-04-30 |  | 0d |  | 32h |
| 316 | 10.1.1 | Functional Results |  | 2d | 2007-04-27 | 2007-04-30 |  | 0d | Development Lead | 16h |
| 317 | 10.1.2 | Performance Results |  | 1d | 2007-04-27 | 2007-04-27 |  | 1d | Architect | 8h |
| 318 | 10.1.3 | Project Schedule Results |  | 0.5d | 2007-04-27 | 2007-04-27 |  | 1.5d | Project Manager | 4h |
| 319 | 10.1.4 | Skills Results |  | 0.5d | 2007-04-27 | 2007-04-27 |  | 1.5d | Project Owner | 4h |
| 320 | 10.2 | Document Lessons Learned |  | 1d | 2007-05-01 | 2007-05-01 | 315 | 0d | Development Lead; Infrastructure Lead; Architect; Test Lead | 32h |
| 321 | 10.3 | Develop Follow-On Plans |  | 2d | 2007-05-02 | 2007-05-03 | 315, 320 | 0d | Project Owner; Project Manager | 32h |
| 322 | 10.4 | Celebrate! |  | 1d | 2007-05-02 | 2007-05-02 | 315, 320 | 0d |  |  |
